# SUMINISTRO DE PEDRAPLÉN PUESTO EN ACOPIO, PARA PREPARACIÓN DE FUNDACIÓN DE CUERPO DE DIQUE SUBPROYEC

Schedule from Primavera P6, 2025-02-20 to 2025-05-20, data date 2025-02-20, costs in PEN.

## Calendars

- Calendario Obra: Mon-Sun 08:00-16:00.

## Resources

| Resource | Group | Rate |
| --- | --- | --- |
| Resources -incentivado | material | 1 |

## Schedule

| ID | WBS | Activity | Type | Duration | Start | Finish | Predecessors | Total float | Resources | Cost |
| --- | --- | --- | --- | --- | --- | --- | --- | --- | --- | --- |
| A1000 |  | CARTA DE ADJUDICACIÓN (LOA) / KOM | milestone | 0d | 2025-02-20 | 2025-02-20 |  | 0d |  |  |
|  | 1 | **MOVILIZACIÓN DEL SUBCONTRATISTA** |  |  | 2025-02-20 | 2025-03-01 |  |  |  |  |
| A1010 |  | PRESENTACIÓN DE CAMOS A MÉDICO OCUPACIONAL |  | 3d | 2025-02-20 | 2025-02-22 | A1000 SS | 0d | Resources -incentivado [24] | 14,779.73 |
| A1020 |  | PRESENTACIÓN DE DOCUMENTACIÓN DE PERSONAL |  | 3d | 2025-02-23 | 2025-02-25 | A1010 | 0d | Resources -incentivado [24] | 11,823.79 |
| A1030 |  | HOMOLOGACIÓN DE EQUIPOS |  | 2d | 2025-02-26 | 2025-02-27 | A1020 | 0d | Resources -incentivado [16] | 11,823.79 |
| A1040 |  | INDUCCIÓN DE PERSONAL |  | 2d | 2025-02-28 | 2025-03-01 | A1030 | 0d | Resources -incentivado [16] | 9,853.16 |
| A1090 |  | MOVILIZACIÓN DE EQUIPOS |  | 2d | 2025-02-28 | 2025-03-01 | A1030 | 80d | Resources -incentivado [16] | 474,922.14 |
|  | 2 | **ROCA EN PEDRAPLEN** |  |  | 2025-03-02 | 2025-05-15 |  |  |  |  |
| A1050 |  | PEDRAPLEN E=0.60m MAX 16" |  | 75d | 2025-03-02 | 2025-05-15 | A1040 | 0d | Resources -incentivado [600] | 4,433,920.43 |
| A1060 |  | PEDRAPLEN E=0.30m MAX 6" |  | 75d | 2025-03-02 | 2025-05-15 | A1050 SS | 0d | Resources -incentivado [600] | 4,433,920.43 |
|  | 3 | **ACTIVIDADES DE DESMOVILIZACIÓN** |  |  | 2025-05-16 | 2025-05-20 |  |  |  |  |
| A1070 |  | DESMOVILIZACIÓN DE EQUIPOS |  | 5d | 2025-05-16 | 2025-05-20 | A1060, A1050 | 0d | Resources -incentivado [40] | 462,113.03 |
| A1080 |  | FIN DE PROYECTO | milestone | 0d | 2025-05-20 | 2025-05-20 | A1070 FF | 0d |  |  |
